# Office Remodel

How a schedule from MS Project changed from version to version. A marks actual dates.

## Version 1 (saved 2019-10-25, file 2_Task Dependencies.mpp)

| ID | WBS | Task | Duration | Start | Finish | Total float |
| --- | --- | --- | --- | --- | --- | --- |
| 1 | 1 | **Space planning** | 5d | 2021-10-12 | 2021-10-18 | 3d |
| 2 |  | Interview space planners | 5d | 2021-10-12 | 2021-10-18 | 3d |
| 3 |  | Hire space planner | 2d | 2021-10-12 | 2021-10-13 | 6d |
| 4 |  | Meet with space planner | 2d | 2021-10-12 | 2021-10-13 | 6d |
| 5 |  | Finalize space plan | 3d | 2021-10-12 | 2021-10-14 | 5d |
| 6 |  | Space planning complete | 0d | 2021-10-12 | 2021-10-12 | 1d |
| 7 | 2 | **Furniture Selection** | 8d | 2021-10-12 | 2021-10-21 | 0d |
| 8 |  | Preview furniture selection | 2d | 2021-10-12 | 2021-10-13 | 6d |
| 9 |  | Select new furniture | 1d | 2021-10-12 | 2021-10-12 | 7d |
| 10 |  | Order new furniture | 0.5d | 2021-10-12 | 2021-10-12 | 7.5d |
| 11 |  | Delivery time | 8d | 2021-10-12 | 2021-10-21 | 0d |
| 12 |  | Furniture delivered | 0d | 2021-10-12 | 2021-10-12 | 8d |
| 13 | 3 | **Office remodel** | 5d | 2021-10-12 | 2021-10-18 | 3d |
| 14 |  | Hire contractor | 4d | 2021-10-12 | 2021-10-15 | 4d |
| 15 |  | Remodel workspace | 5d | 2021-10-12 | 2021-10-18 | 3d |
| 16 |  | Remodel complete | 0d | 2021-10-12 | 2021-10-12 | 1d |
| 17 | 4 | **Move to new office** | 2d? | 2021-10-12 | 2021-10-13 | 6d |
| 18 |  | Hire mover | 2d | 2021-10-12 | 2021-10-13 | 6d |
| 19 |  | Pack workspace | 1d | 2021-10-12 | 2021-10-12 | 7d |
| 20 |  | Move equipment | 0.5d | 2021-10-12 | 2021-10-12 | 7.5d |
| 21 |  | Remove existing furniture | 1d? | 2021-10-12 | 2021-10-12 | 7d |
| 22 |  | Assemble new furniture | 2d | 2021-10-12 | 2021-10-13 | 6d |
| 23 |  | Return equipment | 1d? | 2021-10-12 | 2021-10-12 | 7d |
| 24 |  | Unpack workspace | 2d | 2021-10-12 | 2021-10-13 | 6d |
| 25 |  | Workspace final clean | 1d? | 2021-10-12 | 2021-10-12 | 7d |
| 26 |  | Office remodel complete | 0d | 2021-10-12 | 2021-10-12 | 1d |

## Version 2 (saved 2019-10-25, file 2_Milestones and Durations.mpp)

Last finish 2021-10-21 → 2021-10-12 (-9d).

Removed: 6 Space planning complete; 12 Furniture delivered; 16 Remodel complete

Changed:

| ID | Task | Finish | Duration | Total float | Other |
| --- | --- | --- | --- | --- | --- |
| 1 | **Space planning** | 2021-10-18 → 2021-10-12 (-6d) | 5d → 1d? | 3d → 0d |  |
| 2 | Interview space planners | 2021-10-18 → 2021-10-12 (-6d) | 5d → 1d? | 3d → 0d |  |
| 3 | Hire space planner | 2021-10-13 → 2021-10-12 (-1d) | 2d → 1d? | 6d → 0d |  |
| 4 | Meet with space planner | 2021-10-13 → 2021-10-12 (-1d) | 2d → 1d? | 6d → 0d |  |
| 5 | Finalize space plan | 2021-10-14 → 2021-10-12 (-2d) | 3d → 1d? | 5d → 0d |  |
| 6 | **Furniture selection** | 2021-10-21 → 2021-10-12 (-9d) | 8d → 1d? |  | was named Furniture Selection |
| 7 | Preview furniture selection | 2021-10-13 → 2021-10-12 (-1d) | 2d → 1d? | 6d → 0d |  |
| 8 | Select new furniture |  | 1d → 1d? | 7d → 0d |  |
| 9 | Order new furniture |  | 0.5d → 1d? | 7.5d → 0d |  |
| 10 | Delivery time | 2021-10-21 → 2021-10-12 (-9d) | 8d → 1d? |  |  |
| 11 | **Office remodel** | 2021-10-18 → 2021-10-12 (-6d) | 5d → 1d? | 3d → 0d |  |
| 12 | Hire contractor | 2021-10-15 → 2021-10-12 (-3d) | 4d → 1d? | 4d → 0d |  |
| 13 | Remodel workspace | 2021-10-18 → 2021-10-12 (-6d) | 5d → 1d? | 3d → 0d |  |
| 14 | **Move to new office** | 2021-10-13 → 2021-10-12 (-1d) | 2d? → 1d? | 6d → 0d |  |
| 15 | Hire mover | 2021-10-13 → 2021-10-12 (-1d) | 2d → 1d? | 6d → 0d |  |
| 16 | Pack workspace |  | 1d → 1d? | 7d → 0d |  |
| 17 | Move equipment |  | 0.5d → 1d? | 7.5d → 0d |  |
| 19 | Assemble new furniture | 2021-10-13 → 2021-10-12 (-1d) | 2d → 1d? | 6d → 0d |  |
| 21 | Unpack workspace | 2021-10-13 → 2021-10-12 (-1d) | 2d → 1d? | 6d → 0d |  |
| 23 | Office remodel complete |  | 0d → 1d? | 1d → 0d |  |

## Version 3 (saved 2019-10-25, file 2_Edit Dependencies.mpp)

Last finish 2021-10-12 → 2021-11-23 (+42d).

Added:

| ID | Task | Duration | Start | Finish | Predecessors |
| --- | --- | --- | --- | --- | --- |
| 6 | Space planning complete | 0d | 2021-10-27 | 2021-10-27 | 5 |
| 12 | Furniture delivered | 0d | 2021-11-15 | 2021-11-15 | 11 |
| 16 | Remodel complete | 0d | 2021-11-10 | 2021-11-10 | 15 |

Changed:

| ID | Task | Start | Finish | Duration | Total float | Predecessors | Other |
| --- | --- | --- | --- | --- | --- | --- | --- |
| 1 | **Space planning** |  | 2021-10-12 → 2021-10-27 (+15d) | 1d? → 12d |  |  |  |
| 2 | Interview space planners |  | 2021-10-12 → 2021-10-18 (+6d) | 1d? → 5d |  |  |  |
| 3 | Hire space planner | 2021-10-12 → 2021-10-19 (+7d) | 2021-10-12 → 2021-10-20 (+8d) | 1d? → 2d |  | none → 2 |  |
| 4 | Meet with space planner | 2021-10-12 → 2021-10-21 (+9d) | 2021-10-12 → 2021-10-22 (+10d) | 1d? → 2d |  | none → 3 |  |
| 5 | Finalize space plan | 2021-10-12 → 2021-10-25 (+13d) | 2021-10-12 → 2021-10-27 (+15d) | 1d? → 3d |  | none → 4 |  |
| 7 | **Furniture Selection** | 2021-10-12 → 2021-10-28 (+16d) | 2021-10-12 → 2021-11-15 (+34d) | 1d? → 11.5d |  |  | was named Furniture selection |
| 8 | Preview furniture selection | 2021-10-12 → 2021-10-28 (+16d) | 2021-10-12 → 2021-11-01 (+20d) | 1d? → 2d |  | none → 6 |  |
| 9 | Select new furniture | 2021-10-12 → 2021-11-01 (+20d) | 2021-10-12 → 2021-11-02 (+21d) | 1d? → 1d |  | none → 8 |  |
| 10 | Order new furniture | 2021-10-12 → 2021-11-02 (+21d) | 2021-10-12 → 2021-11-02 (+21d) | 1d? → 0.5d |  | none → 9 |  |
| 11 | Delivery time | 2021-10-12 → 2021-11-03 (+22d) | 2021-10-12 → 2021-11-15 (+34d) | 1d? → 8d |  | none → 10 |  |
| 13 | **Office remodel** | 2021-10-12 → 2021-10-28 (+16d) | 2021-10-12 → 2021-11-10 (+29d) | 1d? → 9d | 0d → 3d |  |  |
| 14 | Hire contractor | 2021-10-12 → 2021-10-28 (+16d) | 2021-10-12 → 2021-11-03 (+22d) | 1d? → 4d | 0d → 3d | none → 6 |  |
| 15 | Remodel workspace | 2021-10-12 → 2021-11-03 (+22d) | 2021-10-12 → 2021-11-10 (+29d) | 1d? → 5d | 0d → 8.5d | none → 14 |  |
| 17 | **Move to new office** | 2021-10-12 → 2021-11-03 (+22d) | 2021-10-12 → 2021-11-23 (+42d) | 1d? → 13.5d? |  |  |  |
| 18 | Hire mover | 2021-10-12 → 2021-11-03 (+22d) | 2021-10-12 → 2021-11-05 (+24d) | 1d? → 2d | 0d → 3d | none → 14 |  |
| 19 | Pack workspace | 2021-10-12 → 2021-11-05 (+24d) | 2021-10-12 → 2021-11-08 (+27d) | 1d? → 1d | 0d → 3d | none → 18 |  |
| 20 | Move equipment | 2021-10-12 → 2021-11-08 (+27d) | 2021-10-12 → 2021-11-08 (+27d) | 1d? → 0.5d | 0d → 3d | none → 19 |  |
| 21 | Remove existing furniture | 2021-10-12 → 2021-11-09 (+28d) | 2021-10-12 → 2021-11-09 (+28d) |  | 0d → 3d | none → 20 |  |
| 22 | Assemble new furniture | 2021-10-12 → 2021-11-16 (+35d) | 2021-10-12 → 2021-11-17 (+36d) | 1d? → 2d |  | none → 21, 12 |  |
| 23 | Return equipment | 2021-10-12 → 2021-11-18 (+37d) | 2021-10-12 → 2021-11-18 (+37d) |  |  | none → 22 |  |
| 24 | Unpack workspace | 2021-10-12 → 2021-11-19 (+38d) | 2021-10-12 → 2021-11-22 (+41d) | 1d? → 2d |  | none → 23 |  |
| 25 | Workspace final clean | 2021-10-12 → 2021-11-23 (+42d) | 2021-10-12 → 2021-11-23 (+42d) |  |  | none → 24 |  |
| 26 | Office remodel complete | 2021-10-12 → 2021-11-23 (+42d) | 2021-10-12 → 2021-11-23 (+42d) | 1d? → 0d |  | none → 25 |  |

## Version 4 (saved 2019-10-25, file 2_Review Project.mpp)

Last finish 2021-11-23 → 2021-11-19 (-4d).

Changed:

| ID | Task | Start | Finish | Duration | Total float | Predecessors |
| --- | --- | --- | --- | --- | --- | --- |
| 13 | **Office remodel** |  | 2021-11-10 → 2021-11-16 (+6d) | 9d → 12d | 3d → 0d |  |
| 15 | Remodel workspace | 2021-11-03 → 2021-11-08 (+5d) | 2021-11-10 → 2021-11-16 (+6d) |  | 8.5d → 0d | 14 → 14FS+3d |
| 16 | Remodel complete | 2021-11-10 → 2021-11-16 (+6d) | 2021-11-10 → 2021-11-16 (+6d) |  | 8.5d → 0d |  |
| 17 | **Move to new office** |  | 2021-11-23 → 2021-11-19 (-4d) | 13.5d? → 11.5d |  |  |
| 19 | Pack workspace | 2021-11-05 → 2021-11-15 (+10d) | 2021-11-08 → 2021-11-16 (+8d) |  | 3d → 0d | 18 → 18, 16FS-1d |
| 20 | Move equipment | 2021-11-08 → 2021-11-16 (+8d) | 2021-11-08 → 2021-11-16 (+8d) |  | 3d → 0d |  |
| 21 | Remove existing furniture | 2021-11-09 → 2021-11-16 (+7d) | 2021-11-09 → 2021-11-17 (+8d) | 1d? → 1d | 3d → 0.5d | 20 → 20SS |
| 22 | Assemble new furniture | 2021-11-16 → 2021-11-17 (+1d) | 2021-11-17 → 2021-11-19 (+2d) |  | 0d → 0.5d |  |
| 23 | Return equipment | 2021-11-18 → 2021-11-17 (-1d) | 2021-11-18 → 2021-11-17 (-1d) | 1d? → 1d | 0d → 2d | 22 → 20 |
| 24 | Unpack workspace | 2021-11-19 → 2021-11-17 (-2d) | 2021-11-22 → 2021-11-18 (-4d) |  |  | 23 → 20 |
| 25 | Workspace final clean | 2021-11-23 → 2021-11-19 (-4d) | 2021-11-23 → 2021-11-19 (-4d) | 1d? → 1d |  |  |
| 26 | Office remodel complete | 2021-11-23 → 2021-11-19 (-4d) | 2021-11-23 → 2021-11-19 (-4d) |  |  |  |

## Version 5 (saved 2019-10-26, file 3_ProjCal.mpp)

Last finish 2021-11-19 → 2021-11-25 (+6d).

Added:

| ID | Task | Duration | Start | Finish | Predecessors | Constraint |
| --- | --- | --- | --- | --- | --- | --- |
| 26 | New office move complete | 0d | 2021-11-25 | 2021-11-25 | 25, 22, 23 | finish no earlier than 2021-11-25 |

Changed:

| ID | Task | Start | Finish | Duration | Total float | Predecessors | Other |
| --- | --- | --- | --- | --- | --- | --- | --- |
| 1 | **Space planning** |  | 2021-10-27 → 2021-10-28 (+1d) | 12d → 13d |  |  |  |
| 2 | Interview space planners |  |  |  | 0d → 1d |  | resources none → Office Manager; Operations Manager; President |
| 3 | Hire space planner |  |  |  | 0d → 1d |  | resources none → President; Administrative Assistant |
| 4 | Meet with space planner |  |  |  | 0d → 1d |  | resources none → Office Manager; Operations Manager; Space Planner; President; Administrative Assistant |
| 5 | Finalize space plan |  |  |  | 0d → 1d |  | resources none → Space Planner |
| 6 | Space planning complete | 2021-10-27 → 2021-10-28 (+1d) | 2021-10-27 → 2021-10-28 (+1d) |  |  |  | constraint none → finish no earlier than 2021-10-28 |
| 7 | **Furniture Selection** | 2021-10-28 → 2021-10-29 (+1d) | 2021-11-15 → 2021-11-16 (+1d) | 11.5d → 11d | 2d → 4.5d |  |  |
| 8 | Preview furniture selection | 2021-10-28 → 2021-10-29 (+1d) | 2021-11-01 → 2021-11-02 (+1d) |  | 2d → 4.5d |  | resources none → Administrative Assistant; Office Manager; Operations Manager |
| 9 | Select new furniture | 2021-11-01 → 2021-11-02 (+1d) | 2021-11-02 → 2021-11-03 (+1d) |  | 2d → 4.5d |  | resources none → Operations Manager; Office Manager |
| 10 | Order new furniture | 2021-11-02 → 2021-11-03 (+1d) | 2021-11-02 → 2021-11-03 (+1d) |  | 2d → 4.5d |  | resources none → Administrative Assistant |
| 11 | Delivery time | 2021-11-03 → 2021-11-04 (+1d) | 2021-11-15 → 2021-11-16 (+1d) | 8d → 7.5d | 2d → 4.5d |  | resources none → Administrative Assistant [10%] |
| 12 | Furniture delivered | 2021-11-15 → 2021-11-16 (+1d) | 2021-11-15 → 2021-11-16 (+1d) |  | 2d → 4.5d |  |  |
| 13 | **Office remodel** | 2021-10-28 → 2021-10-29 (+1d) | 2021-11-16 → 2021-11-18 (+2d) | 12d → 13.5d |  |  |  |
| 14 | Hire contractor | 2021-10-28 → 2021-10-29 (+1d) | 2021-11-03 → 2021-11-04 (+1d) |  | 0d → 1.5d |  | resources none → President; Operations Manager |
| 15 | Remodel workspace | 2021-11-08 → 2021-11-09 (+1d) | 2021-11-16 → 2021-11-17 (+1d) |  | 0d → 1.5d |  | resources none → Contractor |
| 16 | Remodel complete | 2021-11-16 → 2021-11-18 (+2d) | 2021-11-16 → 2021-11-18 (+2d) |  |  |  | constraint none → finish no earlier than 2021-11-18 |
| 17 | **Move to new office** | 2021-11-03 → 2021-11-04 (+1d) | 2021-11-19 → 2021-11-25 (+6d) | 11.5d → 14.5d |  |  |  |
| 18 | Hire mover | 2021-11-03 → 2021-11-04 (+1d) | 2021-11-05 → 2021-11-08 (+3d) |  | 5d → 8d |  | resources none → Operations Manager; Office Manager |
| 19 | Pack workspace | 2021-11-15 → 2021-11-18 (+3d) | 2021-11-16 → 2021-11-18 (+2d) |  | 0d → 1.5d |  | resources none → Office Manager; Mover |
| 20 | Move equipment | 2021-11-16 → 2021-11-19 (+3d) | 2021-11-16 → 2021-11-19 (+3d) |  | 0d → 1.5d |  | resources none → Office Manager; Mover |
| 21 | Remove existing furniture | 2021-11-16 → 2021-11-19 (+3d) | 2021-11-17 → 2021-11-19 (+2d) |  | 0.5d → 2d |  | resources none → Mover |
| 22 | Assemble new furniture | 2021-11-17 → 2021-11-22 (+5d) | 2021-11-19 → 2021-11-23 (+4d) |  | 0.5d → 2d |  | resources none → Space Planner; Mover |
| 23 | Return equipment | 2021-11-17 → 2021-11-19 (+2d) | 2021-11-17 → 2021-11-22 (+5d) |  | 2d → 3.5d |  | resources none → Office Manager; Mover |
| 24 | Unpack workspace | 2021-11-17 → 2021-11-19 (+2d) | 2021-11-18 → 2021-11-23 (+5d) |  | 0d → 1.5d |  | resources none → Administrative Assistant; Mover |
| 25 | Workspace final clean | 2021-11-19 → 2021-11-23 (+4d) | 2021-11-19 → 2021-11-24 (+5d) |  | 0d → 1.5d |  | resources none → Janitor |
| 27 | Office remodel complete | 2021-11-19 → 2021-11-25 (+6d) | 2021-11-19 → 2021-11-25 (+6d) |  |  | 25 → 25, 26 |  |

## Version 6 (saved 2019-10-26, file 3_TaskCal.mpp)

Last finish stays 2021-11-25.

Changed:

| ID | Task | Finish | Total float |
| --- | --- | --- | --- |
| 25 | Workspace final clean | 2021-11-24 → 2021-11-25 (+1d) | 1.5d → 0.5d |

## Version 7 (saved 2019-10-26, file 3_Costs.mpp)

Last finish stays 2021-11-25.

Changed:

| ID | Task | Start | Finish | Total float |
| --- | --- | --- | --- | --- |
| 21 | Remove existing furniture |  | 2021-11-19 → 2021-11-22 (+3d) | 2d → 0.5d |
| 22 | Assemble new furniture | 2021-11-22 → 2021-11-23 (+1d) | 2021-11-23 → 2021-11-24 (+1d) | 2d → 1d |

## Version 8 (saved 2019-10-26, file 4_Constraint.mpp)

Last finish stays 2021-11-25.

Changed:

| ID | Task | Start | Finish | Duration | Total float | Other |
| --- | --- | --- | --- | --- | --- | --- |
| 5 | Finalize space plan |  |  | 3d → 2.25d | 1d → 1.75d |  |
| 7 | **Furniture Selection** |  | 2021-11-16 → 2021-11-17 (+1d) | 11d → 12d | 4.5d → 3.5d |  |
| 8 | Preview furniture selection |  | 2021-11-02 → 2021-11-03 (+1d) | 2d → 3d | 4.5d → 3.5d | resources Administrative Assistant; Office Manager; Operations Manager → Administrative Assistant [20%]; Office Manager [25%]; Operations Manager [25%] |
| 9 | Select new furniture | 2021-11-02 → 2021-11-03 (+1d) | 2021-11-03 → 2021-11-04 (+1d) |  | 4.5d → 3.5d |  |
| 10 | Order new furniture | 2021-11-03 → 2021-11-04 (+1d) | 2021-11-03 → 2021-11-04 (+1d) |  | 4.5d → 3.5d |  |
| 11 | Delivery time | 2021-11-04 → 2021-11-05 (+1d) | 2021-11-16 → 2021-11-17 (+1d) |  | 4.5d → 3.5d |  |
| 12 | Furniture delivered | 2021-11-16 → 2021-11-17 (+1d) | 2021-11-16 → 2021-11-17 (+1d) |  | 4.5d → 3.5d |  |
| 15 | Remodel workspace |  |  |  |  | resources Contractor → Contractor [200%] |
| 25 | Workspace final clean |  | 2021-11-25 → 2021-11-23 (-2d) | 1d → 0.5d | 0.5d → 2d | resources Janitor → Janitor; Mover |

## Version 9 (saved 2019-10-26, file 4_Critical.mpp)

Last finish 2021-11-25 → 2021-11-29 (+4d).

Changed:

| ID | Task | Start | Finish | Duration | Total float | Other |
| --- | --- | --- | --- | --- | --- | --- |
| 7 | **Furniture Selection** | 2021-10-29 → 2021-11-08 (+10d) | 2021-11-17 → 2021-11-25 (+8d) |  | 3.5d → -2.5d |  |
| 8 | Preview furniture selection | 2021-10-29 → 2021-11-08 (+10d) | 2021-11-03 → 2021-11-12 (+9d) |  | 3.5d → -2.5d |  |
| 9 | Select new furniture | 2021-11-03 → 2021-11-12 (+9d) | 2021-11-04 → 2021-11-15 (+11d) |  | 3.5d → -2.5d |  |
| 10 | Order new furniture | 2021-11-04 → 2021-11-15 (+11d) | 2021-11-04 → 2021-11-15 (+11d) |  | 3.5d → -2.5d |  |
| 11 | Delivery time | 2021-11-05 → 2021-11-16 (+11d) | 2021-11-17 → 2021-11-25 (+8d) |  | 3.5d → -2.5d | constraint none → finish no earlier than 2021-11-17 |
| 12 | Furniture delivered | 2021-11-17 → 2021-11-25 (+8d) | 2021-11-17 → 2021-11-25 (+8d) |  | 3.5d → -2.5d |  |
| 17 | **Move to new office** |  | 2021-11-25 → 2021-11-29 (+4d) | 14.5d → 16d | 0d → -1.5d |  |
| 22 | Assemble new furniture | 2021-11-23 → 2021-11-25 (+2d) | 2021-11-24 → 2021-11-29 (+5d) |  | 1d → -1.5d |  |
| 26 | New office move complete | 2021-11-25 → 2021-11-29 (+4d) | 2021-11-25 → 2021-11-29 (+4d) |  | 0d → -1.5d |  |
| 27 | Office remodel complete |  |  |  | 0d → -1.5d | constraint none → must finish on 2021-11-25 |

## Version 10 (saved 2019-10-27, file 5_Resolving.mpp)

Last finish 2021-11-29 → 2021-11-30 (+1d).

Changed:

| ID | Task | Start | Finish | Duration | Total float |
| --- | --- | --- | --- | --- | --- |
| 7 | **Furniture Selection** | 2021-11-08 → 2021-10-29 (-10d) | 2021-11-25 → 2021-11-17 (-8d) | 12d → 12.5d | -2.5d → 1d |
| 8 | Preview furniture selection | 2021-11-08 → 2021-10-29 (-10d) | 2021-11-12 → 2021-11-03 (-9d) |  | -2.5d → 1.5d |
| 9 | Select new furniture | 2021-11-12 → 2021-11-03 (-9d) | 2021-11-15 → 2021-11-04 (-11d) |  | -2.5d → 1.5d |
| 10 | Order new furniture | 2021-11-15 → 2021-11-04 (-11d) | 2021-11-15 → 2021-11-04 (-11d) |  | -2.5d → 1.5d |
| 11 | Delivery time | 2021-11-16 → 2021-11-05 (-11d) | 2021-11-25 → 2021-11-17 (-8d) |  | -2.5d → 1d |
| 12 | Furniture delivered | 2021-11-25 → 2021-11-17 (-8d) | 2021-11-25 → 2021-11-17 (-8d) |  | -2.5d → 1d |
| 17 | **Move to new office** |  | 2021-11-29 → 2021-11-30 (+1d) | 16d → 17.5d | -1.5d → -3d |
| 18 | Hire mover |  | 2021-11-08 → 2021-11-15 (+7d) | 2d → 2.5d | 8.38d → 1d |
| 21 | Remove existing furniture |  | 2021-11-22 → 2021-11-23 (+1d) |  | 0.5d → -1.38d |
| 22 | Assemble new furniture | 2021-11-25 → 2021-11-24 (-1d) | 2021-11-29 → 2021-11-30 (+1d) | 2d → 4d | -1.5d → -3d |
| 23 | Return equipment |  | 2021-11-22 → 2021-11-26 (+4d) | 1d → 2d | 3.5d → -1d |
| 26 | New office move complete | 2021-11-29 → 2021-11-30 (+1d) | 2021-11-29 → 2021-11-30 (+1d) |  | -1.5d → -3d |

## Version 11 (saved 2019-10-28, file 7_Report.mpp)

Last finish 2021-11-30 → 2021-11-25 (-5d).

Changed:

| ID | Task | Start | Finish | Duration | Total float | Other |
| --- | --- | --- | --- | --- | --- | --- |
| 1 | **Space planning** |  |  |  |  | baseline start none → 2021-10-12; baseline finish none → 2021-10-28 |
| 2 | Interview space planners |  |  |  |  | baseline start none → 2021-10-12; baseline finish none → 2021-10-18 |
| 3 | Hire space planner |  |  |  |  | baseline start none → 2021-10-19; baseline finish none → 2021-10-20 |
| 4 | Meet with space planner |  |  |  |  | baseline start none → 2021-10-21; baseline finish none → 2021-10-22 |
| 5 | Finalize space plan |  |  |  |  | baseline start none → 2021-10-25; baseline finish none → 2021-10-27 |
| 6 | Space planning complete |  |  |  |  | baseline start none → 2021-10-28; baseline finish none → 2021-10-28 |
| 7 | **Furniture Selection** |  |  |  | 1d → 3d | baseline start none → 2021-10-29; baseline finish none → 2021-11-17 |
| 8 | Preview furniture selection |  |  |  | 1.5d → 3.5d | resources Administrative Assistant [20%]; Office Manager [25%]; Operations Manager [25%] → Administrative Assistant [20%]; Office Manager [25%]; Space Planner [25%]; baseline start none → 2021-10-29; baseline finish none → 2021-11-03 |
| 9 | Select new furniture |  |  |  | 1.5d → 3.5d | resources Operations Manager; Office Manager → Office Manager; Space Planner; baseline start none → 2021-11-03; baseline finish none → 2021-11-04 |
| 10 | Order new furniture |  |  |  | 1.5d → 3.5d | baseline start none → 2021-11-04; baseline finish none → 2021-11-04 |
| 11 | Delivery time |  |  |  | 1d → 3d | baseline start none → 2021-11-05; baseline finish none → 2021-11-17 |
| 12 | Furniture delivered |  |  |  | 1d → 3d | baseline start none → 2021-11-17; baseline finish none → 2021-11-17 |
| 13 | **Office remodel** |  |  |  | -1.5d → 0d | baseline start none → 2021-10-29; baseline finish none → 2021-11-18 |
| 14 | Hire contractor |  |  |  | 0d → 1.5d | baseline start none → 2021-10-29; baseline finish none → 2021-11-04 |
| 15 | Remodel workspace |  |  |  | 0d → 1.5d | baseline start none → 2021-11-09; baseline finish none → 2021-11-17 |
| 16 | Remodel complete |  |  |  | -1.5d → 0d | baseline start none → 2021-11-18; baseline finish none → 2021-11-18 |
| 17 | **Move to new office** |  | 2021-11-30 → 2021-11-25 (-5d) | 17.5d → 14.5d | -3d → 0d | baseline start none → 2021-11-04; baseline finish none → 2021-11-25 |
| 18 | Hire mover |  |  |  | 1d → 4d | baseline start none → 2021-11-04; baseline finish none → 2021-11-15 |
| 19 | Pack workspace |  |  |  | -1.5d → 1.5d | baseline start none → 2021-11-18; baseline finish none → 2021-11-18 |
| 20 | Move equipment |  |  |  | -1.5d → 1.5d | baseline start none → 2021-11-19; baseline finish none → 2021-11-19 |
| 21 | Remove existing furniture |  |  |  | -1.38d → 0.12d | baseline start none → 2021-11-19; baseline finish none → 2021-11-23 |
| 22 | Assemble new furniture | 2021-11-24 → 2021-11-23 (-1d) | 2021-11-30 → 2021-11-25 (-5d) | 4d → 2d | -3d → 0d | baseline start none → 2021-11-23; baseline finish none → 2021-11-25 |
| 23 | Return equipment |  | 2021-11-26 → 2021-11-22 (-4d) | 2d → 1d | -1d → 3.5d | baseline start none → 2021-11-19; baseline finish none → 2021-11-22 |
| 24 | Unpack workspace |  |  |  | 2d → 1.5d | resources Administrative Assistant; Mover → Administrative Assistant; baseline start none → 2021-11-19; baseline finish none → 2021-11-23 |
| 25 | Workspace final clean |  | 2021-11-23 → 2021-11-25 (+2d) | 0.5d → 1d | 2d → 0.5d | resources Janitor; Mover → Janitor; baseline start none → 2021-11-23; baseline finish none → 2021-11-25 |
| 26 | New office move complete | 2021-11-30 → 2021-11-25 (-5d) | 2021-11-30 → 2021-11-25 (-5d) |  | -3d → 0d | baseline start none → 2021-11-25; baseline finish none → 2021-11-25 |
| 27 | Office remodel complete |  |  |  | -3d → 0d | baseline start none → 2021-11-25; baseline finish none → 2021-11-25 |

## Version 12 (data date 2021-10-20, saved 2019-10-28, file 1_Basic.mpp)

Last finish stays 2021-11-25. Complete tasks 0 → 3.

Changed:

| ID | Task | Start | Finish | Duration | Complete | Total float |
| --- | --- | --- | --- | --- | --- | --- |
| 1 | **Space planning** | 2021-10-12 A |  |  | 0% → 86% |  |
| 2 | Interview space planners | 2021-10-12 A | 2021-10-18 → 2021-10-14 A (-4d) | 5d → 3d | 0% → 100% | 1.75d → none |
| 3 | Hire space planner | 2021-10-19 → 2021-10-15 A (-4d) | 2021-10-20 → 2021-10-18 A (-2d) |  | 0% → 100% | 1.75d → none |
| 4 | Meet with space planner | 2021-10-21 → 2021-10-19 A (-2d) | 2021-10-22 → 2021-10-20 A (-2d) |  | 0% → 100% | 1.75d → none |
| 5 | Finalize space plan | 2021-10-25 → 2021-10-21 A (-4d) | 2021-10-27 → 2021-10-25 (-2d) |  | 0% → 44% | 1.75d → 3.75d |
| 17 | **Move to new office** | 2021-11-04 A |  |  | 0% → 13% |  |
| 23 | Return equipment | 2021-11-19 → 2021-11-22 A (+3d) | 2021-11-22 → 2021-11-23 (+1d) | 1d → 1.5d | 0% → 99% | 3.5d → 2.5d |

## Version 13 (saved 2020-03-19, file 3_Resources.mpp)

Last finish stays 2021-11-25. Complete tasks 3 → 0.

Changed:

| ID | Task | Start | Finish | Duration | Complete | Total float | Other |
| --- | --- | --- | --- | --- | --- | --- | --- |
| 1 | **Space planning** | 2021-10-12 A → 2021-10-12 |  |  | 86% → 0% |  | baseline start 2021-10-12 → none; baseline finish 2021-10-28 → none |
| 2 | Interview space planners | 2021-10-12 A → 2021-10-12 | 2021-10-14 A → 2021-10-18 (+4d) | 3d → 5d | 100% → 0% | none → 1d | resources Office Manager; Operations Manager; President → none; baseline start 2021-10-12 → none; baseline finish 2021-10-18 → none |
| 3 | Hire space planner | 2021-10-15 A → 2021-10-19 (+4d) | 2021-10-18 A → 2021-10-20 (+2d) |  | 100% → 0% | none → 1d | resources President; Administrative Assistant → none; baseline start 2021-10-19 → none; baseline finish 2021-10-20 → none |
| 4 | Meet with space planner | 2021-10-19 A → 2021-10-21 (+2d) | 2021-10-20 A → 2021-10-22 (+2d) |  | 100% → 0% | none → 1d | resources Office Manager; Operations Manager; Space Planner; President; Administrative Assistant → none; baseline start 2021-10-21 → none; baseline finish 2021-10-22 → none |
| 5 | Finalize space plan | 2021-10-21 A → 2021-10-25 (+4d) | 2021-10-25 → 2021-10-27 (+2d) | 2.25d → 3d | 44% → 0% | 3.75d → 1d | resources Space Planner → none; baseline start 2021-10-25 → none; baseline finish 2021-10-27 → none |
| 6 | Space planning complete |  |  |  |  |  | baseline start 2021-10-28 → none; baseline finish 2021-10-28 → none |
| 7 | **Furniture Selection** |  | 2021-11-17 → 2021-11-16 (-1d) | 12.5d → 11.5d |  | 3d → 4d | baseline start 2021-10-29 → none; baseline finish 2021-11-17 → none |
| 8 | Preview furniture selection |  | 2021-11-03 → 2021-11-02 (-1d) | 3d → 2d |  | 3.5d → 4d | resources Administrative Assistant [20%]; Office Manager [25%]; Space Planner [25%] → none; baseline start 2021-10-29 → none; baseline finish 2021-11-03 → none |
| 9 | Select new furniture | 2021-11-03 → 2021-11-02 (-1d) | 2021-11-04 → 2021-11-03 (-1d) |  |  | 3.5d → 4d | resources Office Manager; Space Planner → none; baseline start 2021-11-03 → none; baseline finish 2021-11-04 → none |
| 10 | Order new furniture | 2021-11-04 → 2021-11-03 (-1d) | 2021-11-04 → 2021-11-03 (-1d) |  |  | 3.5d → 4d | resources Administrative Assistant → none; baseline start 2021-11-04 → none; baseline finish 2021-11-04 → none |
| 11 | Delivery time | 2021-11-05 → 2021-11-04 (-1d) | 2021-11-17 → 2021-11-16 (-1d) | 7.5d → 8d |  | 3d → 4d | constraint finish no earlier than 2021-11-17 → none; resources Administrative Assistant [10%] → none; baseline start 2021-11-05 → none; baseline finish 2021-11-17 → none |
| 12 | Furniture delivered | 2021-11-17 → 2021-11-16 (-1d) | 2021-11-17 → 2021-11-16 (-1d) |  |  | 3d → 4d | baseline start 2021-11-17 → none; baseline finish 2021-11-17 → none |
| 13 | **Office remodel** |  |  |  |  |  | baseline start 2021-10-29 → none; baseline finish 2021-11-18 → none |
| 14 | Hire contractor |  |  |  |  |  | resources President; Operations Manager → none; baseline start 2021-10-29 → none; baseline finish 2021-11-04 → none |
| 15 | Remodel workspace |  |  |  |  |  | resources Contractor [200%] → none; baseline start 2021-11-09 → none; baseline finish 2021-11-17 → none |
| 16 | Remodel complete |  |  |  |  |  | baseline start 2021-11-18 → none; baseline finish 2021-11-18 → none |
| 17 | **Move to new office** | 2021-11-04 A → 2021-11-04 |  |  | 13% → 0% |  | baseline start 2021-11-04 → none; baseline finish 2021-11-25 → none |
| 18 | Hire mover |  | 2021-11-15 → 2021-11-08 (-7d) | 2.5d → 2d |  | 4d → 8d | resources Operations Manager; Office Manager → none; baseline start 2021-11-04 → none; baseline finish 2021-11-15 → none |
| 19 | Pack workspace |  |  |  |  |  | resources Office Manager; Mover → none; baseline start 2021-11-18 → none; baseline finish 2021-11-18 → none |
| 20 | Move equipment |  |  |  |  |  | resources Office Manager; Mover → none; baseline start 2021-11-19 → none; baseline finish 2021-11-19 → none |
| 21 | Remove existing furniture |  | 2021-11-23 → 2021-11-19 (-4d) |  |  | 0.12d → 2d | resources Mover → none; baseline start 2021-11-19 → none; baseline finish 2021-11-23 → none |
| 22 | Assemble new furniture | 2021-11-23 → 2021-11-22 (-1d) | 2021-11-25 → 2021-11-23 (-2d) |  |  | 0d → 2d | resources Space Planner; Mover → none; baseline start 2021-11-23 → none; baseline finish 2021-11-25 → none |
| 23 | Return equipment | 2021-11-22 A → 2021-11-19 (-3d) | 2021-11-23 → 2021-11-22 (-1d) | 1.5d → 1d | 99% → 0% | 2.5d → 3.5d | resources Office Manager; Mover → none; baseline start 2021-11-19 → none; baseline finish 2021-11-22 → none |
| 24 | Unpack workspace |  |  |  |  |  | resources Administrative Assistant → none; baseline start 2021-11-19 → none; baseline finish 2021-11-23 → none |
| 25 | Workspace final clean |  | 2021-11-25 → 2021-11-24 (-1d) |  |  | 0.5d → 1.5d | resources Janitor → none; baseline start 2021-11-23 → none; baseline finish 2021-11-25 → none |
| 26 | New office move complete |  |  |  |  |  | baseline start 2021-11-25 → none; baseline finish 2021-11-25 → none |
| 27 | Office remodel complete |  |  |  |  |  | constraint must finish on 2021-11-25 → none; baseline start 2021-11-25 → none; baseline finish 2021-11-25 → none |

## Version 14 (saved 2020-03-24, file 6_Formatting.mpp)

Last finish stays 2021-11-25.

Changed:

| ID | Task | Start | Finish | Duration | Total float | Other |
| --- | --- | --- | --- | --- | --- | --- |
| 2 | Interview space planners |  |  |  | 1d → 1.75d | resources none → Office Manager; Operations Manager; President |
| 3 | Hire space planner |  |  |  | 1d → 1.75d | resources none → President; Administrative Assistant |
| 4 | Meet with space planner |  |  |  | 1d → 1.75d | resources none → Office Manager; Operations Manager; Space Planner; President; Administrative Assistant |
| 5 | Finalize space plan |  |  | 3d → 2.25d | 1d → 1.75d | resources none → Space Planner |
| 7 | **Furniture Selection** |  | 2021-11-16 → 2021-11-17 (+1d) | 11.5d → 12.5d | 4d → 3d |  |
| 8 | Preview furniture selection |  | 2021-11-02 → 2021-11-03 (+1d) | 2d → 3d | 4d → 3.5d | resources none → Administrative Assistant [20%]; Office Manager [25%]; Space Planner [25%] |
| 9 | Select new furniture | 2021-11-02 → 2021-11-03 (+1d) | 2021-11-03 → 2021-11-04 (+1d) |  | 4d → 3.5d | resources none → Office Manager; Space Planner |
| 10 | Order new furniture | 2021-11-03 → 2021-11-04 (+1d) | 2021-11-03 → 2021-11-04 (+1d) |  | 4d → 3.5d | resources none → Administrative Assistant |
| 11 | Delivery time | 2021-11-04 → 2021-11-05 (+1d) | 2021-11-16 → 2021-11-17 (+1d) | 8d → 7.5d | 4d → 3d | constraint none → finish no earlier than 2021-11-17; resources none → Administrative Assistant [10%] |
| 12 | Furniture delivered | 2021-11-16 → 2021-11-17 (+1d) | 2021-11-16 → 2021-11-17 (+1d) |  | 4d → 3d |  |
| 14 | Hire contractor |  |  |  |  | resources none → President; Operations Manager |
| 15 | Remodel workspace |  |  |  |  | resources none → Contractor [200%] |
| 18 | Hire mover |  | 2021-11-08 → 2021-11-15 (+7d) | 2d → 2.5d | 8d → 4d | resources none → Operations Manager; Office Manager |
| 19 | Pack workspace |  |  |  |  | resources none → Office Manager; Mover |
| 20 | Move equipment |  |  |  |  | resources none → Office Manager; Mover |
| 21 | Remove existing furniture |  | 2021-11-19 → 2021-11-23 (+4d) |  | 2d → 0.12d | resources none → Mover |
| 22 | Assemble new furniture | 2021-11-22 → 2021-11-23 (+1d) | 2021-11-23 → 2021-11-25 (+2d) |  | 2d → 0d | resources none → Space Planner; Mover |
| 23 | Return equipment |  |  |  |  | resources none → Office Manager; Mover |
| 24 | Unpack workspace |  |  |  |  | resources none → Administrative Assistant |
| 25 | Workspace final clean |  | 2021-11-24 → 2021-11-25 (+1d) |  | 1.5d → 0.5d | resources none → Janitor |
| 27 | Office remodel complete |  |  |  |  | constraint none → must finish on 2021-11-25 |

## Version 15 (saved 2020-03-26, file 9_Update.mpp)

Last finish stays 2021-11-25.

Changed:

| ID | Task | Other |
| --- | --- | --- |
| 1 | **Space planning** | baseline start none → 2021-10-12; baseline finish none → 2021-10-28 |
| 2 | Interview space planners | baseline start none → 2021-10-12; baseline finish none → 2021-10-18 |
| 3 | Hire space planner | baseline start none → 2021-10-19; baseline finish none → 2021-10-20 |
| 4 | Meet with space planner | baseline start none → 2021-10-21; baseline finish none → 2021-10-22 |
| 5 | Finalize space plan | baseline start none → 2021-10-25; baseline finish none → 2021-10-27 |
| 6 | Space planning complete | baseline start none → 2021-10-28; baseline finish none → 2021-10-28 |
| 7 | **Furniture Selection** | baseline start none → 2021-10-29; baseline finish none → 2021-11-17 |
| 8 | Preview furniture selection | baseline start none → 2021-10-29; baseline finish none → 2021-11-03 |
| 9 | Select new furniture | baseline start none → 2021-11-03; baseline finish none → 2021-11-04 |
| 10 | Order new furniture | baseline start none → 2021-11-04; baseline finish none → 2021-11-04 |
| 11 | Delivery time | baseline start none → 2021-11-05; baseline finish none → 2021-11-17 |
| 12 | Furniture delivered | baseline start none → 2021-11-17; baseline finish none → 2021-11-17 |
| 13 | **Office remodel** | baseline start none → 2021-10-29; baseline finish none → 2021-11-18 |
| 14 | Hire contractor | baseline start none → 2021-10-29; baseline finish none → 2021-11-04 |
| 15 | Remodel workspace | baseline start none → 2021-11-09; baseline finish none → 2021-11-17 |
| 16 | Remodel complete | baseline start none → 2021-11-18; baseline finish none → 2021-11-18 |
| 17 | **Move to new office** | baseline start none → 2021-11-04; baseline finish none → 2021-11-25 |
| 18 | Hire mover | baseline start none → 2021-11-04; baseline finish none → 2021-11-15 |
| 19 | Pack workspace | baseline start none → 2021-11-18; baseline finish none → 2021-11-18 |
| 20 | Move equipment | baseline start none → 2021-11-19; baseline finish none → 2021-11-19 |
| 21 | Remove existing furniture | baseline start none → 2021-11-19; baseline finish none → 2021-11-23 |
| 22 | Assemble new furniture | baseline start none → 2021-11-23; baseline finish none → 2021-11-25 |
| 23 | Return equipment | baseline start none → 2021-11-19; baseline finish none → 2021-11-22 |
| 24 | Unpack workspace | baseline start none → 2021-11-19; baseline finish none → 2021-11-23 |
| 25 | Workspace final clean | baseline start none → 2021-11-23; baseline finish none → 2021-11-25 |
| 26 | New office move complete | baseline start none → 2021-11-25; baseline finish none → 2021-11-25 |
| 27 | Office remodel complete | baseline start none → 2021-11-25; baseline finish none → 2021-11-25 |

## Version 16 (data date 2021-10-21, saved 2020-03-30, file 9_Compare.mpp)

Last finish stays 2021-11-25. Complete tasks 0 → 4.

Changed:

| ID | Task | Start | Finish | Duration | Complete | Total float |
| --- | --- | --- | --- | --- | --- | --- |
| 1 | **Space planning** | 2021-10-12 A |  |  | 0% → 99% |  |
| 2 | Interview space planners | 2021-10-12 A | 2021-10-18 → 2021-10-14 A (-4d) | 5d → 3d | 0% → 100% | 1.75d → none |
| 3 | Hire space planner | 2021-10-19 → 2021-10-20 A (+1d) | 2021-10-20 → 2021-10-21 A (+1d) |  | 0% → 100% | 1.75d → none |
| 4 | Meet with space planner | 2021-10-21 → 2021-10-20 A (-1d) | 2021-10-22 → 2021-10-21 A (-1d) |  | 0% → 100% | 1.75d → none |
| 5 | Finalize space plan | 2021-10-25 → 2021-10-22 A (-3d) | 2021-10-27 → 2021-10-26 A (-1d) |  | 0% → 100% | 1.75d → none |
| 17 | **Move to new office** | 2021-11-04 A |  |  | 0% → 9% |  |
| 23 | Return equipment | 2021-11-19 → 2021-11-22 A (+3d) | 2021-11-22 → 2021-11-23 (+1d) | 1d → 1.5d | 0% → 67% | 3.5d → 2.5d |
